# \\scdata2\strategicbusinessservice\SSDM\Scheduling Task Force\Templates\ADA Templates\Region 2 - ADA Projects [Outsourced] Template (6-9-20)

Schedule from MS Project, 2020-05-29 to 2024-04-08.

## Calendars

- ODOT: Mon-Fri 08:00-12:00, 13:00-17:00; Sat-Sun off. Exceptions (off unless hours are given): 2020-07-03 (Independence Day 2020), 2020-09-07 (Labor Day 2020), 2020-11-11 (Veterans Day 2020), 2020-11-26 (Thanksgiving #1 2020), 2020-11-27 (Thanksgiving #2 2020), 2020-12-25 (Christmas Day 2020), 2021-01-01 (New Year's Day 2021), 2021-01-18 (MLK Day 2021), 2021-02-15 (Presidents Day 2021), 2021-05-31 (Memorial Day 2021), 2021-07-05 (Independence Day 2021), 2021-09-06 (Labor Day 2021), 2021-11-11 (Veterans Day 2021), 2021-11-25 (Thanksgiving 2021), 2021-12-24 (Christmas Day 2021), 2021-12-31, 2022-01-17 (MLK Day 2022), 2022-02-21 (Presidents Day 2022), 2022-05-30 (Memorial Day 2022), 2022-07-04 (Independence Day 2022), 2022-09-05 (Labor Day 2022), 2022-11-11 (Veterans Day 2022), 2022-11-24 to 2022-11-25 (Thanksgiving #1 2022), 2022-12-26 (Christmas Day 2022), 2023-01-02 (New Years Day 2023), 2023-01-23 (MLK Day 2023), 2023-02-20 (Presidents Day 2023), 2023-05-29 (Memorial Day 2023), 2023-06-19 (Juneteenth 2023), 2023-07-04 (Independence Day 2023), 2023-09-04 (Labor Day 2023), 2023-11-10 (Veterans Day 2023), 2023-11-23 (Thanksgiving Day #1 2023), 2023-11-24 (Thanksgiving #2 2023), 2023-12-25 (Christmas Day 2023), 2024-01-01 (New Years Day 2024), 2024-01-15 (MLK Day 2024), 2024-02-19 (Presidents Day 2024).

## Schedule

| ID | WBS | Task | Type | Duration | Start | Finish | Predecessors | Total slack |
| --- | --- | --- | --- | --- | --- | --- | --- | --- |
| 1 | 1 | **ADA Curb ramp only Projects [Outsourced] Template (5-1-2023)** |  | 558d | 2020-05-29 | 2022-08-16 |  | 0d |
| 2 | 1.1 | **Phase 1: Project Initiation** |  | 40d | 2020-05-29 | 2020-07-24 |  | 0d |
| 3 | 1.1.1 | Project Intitation Start date | milestone | 0d | 2020-05-29 | 2020-05-29 |  | 0d |
| 4 | 1.1.2 | PE EA Open | milestone | 0d | 2020-05-29 | 2020-05-29 | 3 | 0d |
| 5 | 1.1.3 | Project Kick Off |  | 1d | 2020-05-29 | 2020-05-29 | 4 | 0d |
| 6 | 1.1.4 | Program WZDT, RR, PIP, project schedule development |  | 39d | 2020-06-01 | 2020-07-24 | 5 | 0d |
| 7 | 1.1.5 | Project Initiation Phase Complete | milestone | 0d | 2020-07-24 | 2020-07-24 | 6 | 0d |
| 8 | 1.2 | **Phase 2: Concept Plans** |  | 100d | 2020-07-27 | 2020-12-17 |  | 0d |
| 9 | 1.2.1 | Concept plan development |  | 90d | 2020-07-27 | 2020-12-03 | 7 | 0d |
| 10 | 1.2.2 | Concept plan review |  | 80d | 2020-08-24 | 2020-12-17 | 9SS+20d | 0d |
| 11 | 1.2.3 | Concept plan concurrence (program phase gate) | milestone | 0d | 2020-12-17 | 2020-12-17 | 10 | 0d |
| 12 | 1.2.4 | Early ROW Descriptions | milestone | 0d | 2020-12-17 | 2020-12-17 | 10 | 828d |
| 13 | 1.3 | **Phase 3: Design Acceptance Plans (DAP)** |  | 100d | 2020-12-18 | 2021-05-12 |  | 0d |
| 14 | 1.3.1 | DAP Plans Development |  | 90d | 2020-12-18 | 2021-04-28 | 11 | 0d |
| 15 | 1.3.2 | Desgin Execption/Crosswalk Closure Workshops |  | 90d | 2020-12-18 | 2021-04-28 | 14SS | 0d |
| 16 | 1.3.3 | DAP Plans and Cost Estimate Submittal | milestone | 0d | 2021-04-28 | 2021-04-28 | 14, 15 | 0d |
| 17 | 1.3.4 | DAP Plan review |  | 10d | 2021-04-29 | 2021-05-12 | 16 | 0d |
| 18 | 1.3.5 | DAP Certification | milestone | 0d | 2021-05-12 | 2021-05-12 | 17 | 0d |
| 19 | 1.4 | CMR0 & STIP amendment |  | 60d | 2021-05-13 | 2021-08-06 | 18 | 668d |
| 20 | 1.5 | **Phase 4: Right of Way Acquisition** |  | 280d | 2021-05-13 | 2022-06-22 |  | 0d |
| 21 | 1.5.1 | ROW Descriptions |  | 40d | 2021-05-13 | 2021-07-09 | 18 | 0d |
| 22 | 1.5.2 | ROW EA Open | milestone | 0d | 2021-08-06 | 2021-08-06 | 21FS+20d | 0d |
| 23 | 1.5.3 | ROW Acquistion |  | 220d | 2021-08-09 | 2022-06-22 | 22 | 0d |
| 24 | 1.5.4 | ROW Certification | milestone | 0d | 2022-06-22 | 2022-06-22 | 23 | 0d |

Notes:
- 15: New Act ID
- 16: Instead of 024, new Act ID

| ID | WBS | Task | Type | Duration | Start | Finish | Predecessors | Total slack | Free slack |
| --- | --- | --- | --- | --- | --- | --- | --- | --- | --- |
| 25 | 1.6 | **Phase 5 Final Plans** |  | 280d | 2021-05-13 | 2022-06-22 |  | 0d |  |
| 26 | 1.6.1 | Final Plans Development |  | 240d | 2021-05-13 | 2022-04-26 | 18 | 0d |  |
| 27 | 1.6.2 | Pre-Final Specs & Estimate | milestone | 0d | 2022-03-29 | 2022-03-29 | 26FF-20d | 508d |  |
| 28 | 1.6.3 | Final Crosswalk Closure Submittal | milestone | 0d | 2022-03-01 | 2022-03-01 | 26FF-40d | 528d | 20d |
| 29 | 1.6.4 | Final Design Exception Submittal | milestone | 0d | 2022-03-29 | 2022-03-29 | 26FF-20d, 28 | 508d |  |
| 30 | 1.6.5 | Final Plans review period |  | 10d | 2022-04-27 | 2022-05-10 | 26 | 0d |  |
| 31 | 1.6.6 | Update Final Plans |  | 20d | 2022-05-11 | 2022-06-08 | 30 | 0d |  |
| 32 | 1.6.7 | TCM PS&E submittal review |  | 10d | 2022-06-09 | 2022-06-22 | 31 | 0d |  |
| 33 | 1.7 | **Phase 6: PS&E - Bid** |  | 38d | 2022-06-22 | 2022-08-16 |  | 0d |  |
| 34 | 1.7.1 | PS&E Package to the Project Controls Office (PCO) | milestone | 0d | 2022-06-22 | 2022-06-22 | 32, 24 | 0d |  |
| 35 | 1.7.2 | Pre-Letting Review |  | 23d | 2022-06-23 | 2022-07-26 | 34 | 0d |  |
| 36 | 1.7.3 | Advertisement |  | 15d | 2022-07-27 | 2022-08-16 | 35 | 0d |  |
| 37 | 1.7.4 | Bid Opening | milestone | 0d | 2022-08-16 | 2022-08-16 | 36 | 0d |  |
| 38 | 2 | **Phase 7: Construction Phase** |  | 968d? | 2020-05-29 | 2024-04-08 |  | 0d |  |
| 39 | 2.1 | 1st Note | milestone | 0d | 2022-10-26 | 2022-10-26 | 37FS+50d | 0d |  |
| 40 | 2.2 | 2nd Note | milestone | 0d | 2023-10-12 | 2023-10-12 | 39FS+240d | 0d |  |
| 41 | 2.3 | 3rd Note | milestone | 0d | 2024-04-08 | 2024-04-08 | 40FS+120d | 0d |  |

Notes:
- 27: New Act ID
- 28: New Act ID
- 29: New Act ID
